# project schedule

Schedule from MS Project, 2007-07-02 to 2008-07-29.
Augsburg College

## Calendars

- Standard: Mon-Fri 08:00-12:00, 13:00-17:00; Sat-Sun off.

## Schedule

| ID | WBS | Task | Type | Duration | Start | Finish | Predecessors | Total slack | Free slack | Constraint |
| --- | --- | --- | --- | --- | --- | --- | --- | --- | --- | --- |
| 1 | 1 | **Initiating** |  | 16d | 2007-07-02 | 2007-07-23 |  | 0d |  |  |
| 2 | 1.1 | Prepare stakeholder analysis |  | 3d | 2007-07-02 | 2007-07-04 |  | 0d |  |  |
| 3 | 1.2 | Prepare business case |  | 5d | 2007-07-05 | 2007-07-11 | 2 | 0d |  |  |
| 4 | 1.3 | Create project charter |  | 3d | 2007-07-12 | 2007-07-16 | 3 | 0d |  |  |
| 5 | 1.4 | Hold project kickoff meeting | milestone | 0d | 2007-07-16 | 2007-07-16 | 4 | 271d |  |  |
| 6 | 1.5 | Develop preliminary scope statement |  | 5d | 2007-07-17 | 2007-07-23 | 4 | 0d |  |  |
| 7 | 2 | **Planning** |  | 53d | 2007-07-05 | 2007-09-17 |  | 226d |  |  |
| 8 | 2.1 | **Project integration management** |  | 53d | 2007-07-05 | 2007-09-17 |  | 226d |  |  |
| 9 | 2.1.1 | Create team contract |  | 3d | 2007-07-05 | 2007-07-09 | 2 | 276d |  |  |
| 10 | 2.1.2 | Develop project management plan |  | 51d | 2007-07-09 | 2007-09-17 |  | 226d |  | start no earlier than 2007-07-09 |
| 11 | 2.2 | **Project scope management** |  | 10d | 2007-07-24 | 2007-08-06 |  | 226d |  |  |
| 12 | 2.2.1 | Develop scope statement |  | 7d | 2007-07-24 | 2007-08-01 | 6 | 226d | 0d |  |
| 13 | 2.2.2 | Create WBS and WBS dictionary |  | 3d | 2007-08-02 | 2007-08-06 | 12 | 226d | 0d |  |
| 14 | 2.3 | Project time management |  | 10d | 2007-08-07 | 2007-08-20 | 13 | 226d | 0d |  |
| 15 | 2.4 | Project cost management |  | 10d | 2007-08-07 | 2007-08-20 | 13 | 246d |  |  |
| 16 | 2.5 | Project quality management |  | 10d | 2007-08-07 | 2007-08-20 | 13 | 246d |  |  |
| 17 | 2.6 | Project human resource management |  | 10d | 2007-08-07 | 2007-08-20 | 13 | 246d |  |  |
| 18 | 2.7 | Project communications management |  | 10d | 2007-08-21 | 2007-09-03 | 14 | 236d |  |  |
| 19 | 2.8 | Project risk management |  | 10d | 2007-08-21 | 2007-09-03 | 14 | 236d |  |  |
| 20 | 2.9 | Project procurement management |  | 20d | 2007-08-21 | 2007-09-17 | 14 | 226d |  |  |
| 21 | 3 | **Executing** |  | 251d? | 2007-07-16 | 2008-06-30 |  | 6d |  |  |
| 22 | 3.1 | **Course design and development** |  | 94d | 2007-07-24 | 2007-11-30 |  | 0d |  |  |
| 23 | 3.1.1 | **Supplier management training:** |  | 94d | 2007-07-24 | 2007-11-30 |  | 0d |  |  |
| 24 | 3.1.1.1 | **Needs assessment** |  | 24d | 2007-07-24 | 2007-08-24 |  | 0d |  |  |
| 25 | 3.1.1.1.1 | Develop survey |  | 12d | 2007-07-24 | 2007-08-08 | 6 | 0d |  |  |
| 26 | 3.1.1.1.2 | Administer survey |  | 2d | 2007-08-09 | 2007-08-10 | 25 | 0d |  |  |
| 27 | 3.1.1.1.3 | Analyze survey results |  | 10d | 2007-08-13 | 2007-08-24 | 26 | 0d |  |  |
| 28 | 3.1.1.1.4 | Survey results reported to steering committee | milestone | 0d | 2007-08-24 | 2007-08-24 | 27 | 0d |  |  |
| 29 | 3.1.1.2 | Research of existing training |  | 15d | 2007-07-24 | 2007-08-13 | 6 | 251d |  |  |

| ID | WBS | Task | Type | Duration | Start | Finish | Predecessors | Total slack | Free slack |
| --- | --- | --- | --- | --- | --- | --- | --- | --- | --- |
| 30 | 3.1.1.3 | **Partnerships** |  | 25d | 2007-08-27 | 2007-09-28 |  | 0d |  |
| 31 | 3.1.1.3.1 | Research potential partners for providing training |  | 10d | 2007-08-27 | 2007-09-07 | 28 | 0d |  |
| 32 | 3.1.1.3.2 | Meet with potential partners |  | 10d | 2007-09-10 | 2007-09-21 | 31 | 0d |  |
| 33 | 3.1.1.3.3 | Develop partnership agreements |  | 5d | 2007-09-24 | 2007-09-28 | 32 | 0d |  |
| 34 | 3.1.1.4 | **Course development** |  | 40d | 2007-10-01 | 2007-11-23 |  | 0d |  |
| 35 | 3.1.1.4.1 | Develop executive course |  | 30d | 2007-10-01 | 2007-11-09 | 33 | 187d |  |
| 36 | 3.1.1.4.2 | Develop introductory course |  | 30d | 2007-10-01 | 2007-11-09 | 33 | 0d |  |
| 37 | 3.1.1.4.3 | Develop advanced course |  | 40d | 2007-10-01 | 2007-11-23 | 33 | 177d |  |
| 38 | 3.1.1.5 | **Pilot course** |  | 15d | 2007-11-12 | 2007-11-30 |  | 0d |  |
| 39 | 3.1.1.5.1 | Plan pilot course |  | 10d | 2007-11-12 | 2007-11-23 | 36 | 0d |  |
| 40 | 3.1.1.5.2 | Hold pilot course | milestone | 0d | 2007-11-23 | 2007-11-23 | 39 | 0d |  |
| 41 | 3.1.1.5.3 | Prepare report on pilot course |  | 3d | 2007-11-26 | 2007-11-28 | 40 | 0d |  |
| 42 | 3.1.1.5.4 | Review results of pilot course |  | 2d | 2007-11-29 | 2007-11-30 | 41 | 0d |  |
| 43 | 3.1.1.5.5 | Results reported to steering committee | milestone | 0d | 2007-11-30 | 2007-11-30 | 42 | 0d |  |
| 44 | 3.1.2 | Negotiating skills training |  | 80d | 2007-07-24 | 2007-11-12 | 6 | 76d | 0d |
| 45 | 3.1.3 | Project management training |  | 80d | 2007-07-24 | 2007-11-12 | 6 | 66d | 0d |
| 46 | 3.1.4 | Software applications training |  | 80d | 2007-07-24 | 2007-11-12 | 6 | 126d | 0d |
| 47 | 3.2 | **Course Administration** |  | 96d | 2007-12-14 | 2008-04-28 |  | 20d |  |
| 48 | 3.2.1 | First supplier management executive course completed | milestone | 0d | 2008-01-11 | 2008-01-11 | 43FS+30d | 0d |  |
| 49 | 3.2.2 | First supplier management introductory course completed | milestone | 0d | 2007-12-14 | 2007-12-14 | 43FS+10d | 72d | 0d |
| 50 | 3.2.3 | Second supplier management introductory course completed | milestone | 0d | 2008-01-25 | 2008-01-25 | 49FS+30d | 72d | 0d |
| 51 | 3.2.4 | Third supplier management introductory course completed | milestone | 0d | 2008-04-18 | 2008-04-18 | 50FS+60d | 72d |  |
| 52 | 3.2.5 | First supplier management advanced course | milestone | 0d | 2008-02-08 | 2008-02-08 | 43FS+50d | 122d |  |
| 53 | 3.2.6 | First negotiating skills course completed | milestone | 0d | 2008-01-21 | 2008-01-21 | 44FS+50d | 76d | 0d |
| 54 | 3.2.7 | Second negotiating skills course completed | milestone | 0d | 2008-04-14 | 2008-04-14 | 53FS+60d | 76d |  |
| 55 | 3.2.8 | First project management course completed | milestone | 0d | 2008-02-04 | 2008-02-04 | 45FS+60d | 66d | 0d |
| 56 | 3.2.9 | Second project management course completed | milestone | 0d | 2008-04-28 | 2008-04-28 | 55FS+60d | 66d |  |
| 57 | 3.2.10 | First software applications course completed | milestone | 0d | 2008-02-04 | 2008-02-04 | 46FS+60d | 126d |  |

| ID | WBS | Task | Type | Duration | Start | Finish | Predecessors | Total slack | Constraint |
| --- | --- | --- | --- | --- | --- | --- | --- | --- | --- |
| 58 | 3.3 | **Course Evaluation** |  | 121d? | 2008-01-14 | 2008-06-30 | 48 | 0d |  |
| 59 | 3.3.1 | Prepare evaluations of all courses |  | 118d? | 2008-01-14 | 2008-06-25 |  | 0d | start no earlier than 2007-12-14 |
| 60 | 3.3.2 | Prepare summary of all evaluations |  | 3d | 2008-06-26 | 2008-06-30 | 59 | 0d |  |
| 61 | 3.3.3 | Summary of course evaluations reported to steering committee | milestone | 0d | 2008-06-30 | 2008-06-30 | 60 | 0d |  |
| 62 | 3.4 | **Stakeholder Communications** |  | 230.5d? | 2007-07-16 | 2008-06-02 |  | 41.5d |  |
| 63 | 3.4.1 | **Communications regarding project and changes to training** |  | 209d? | 2007-07-16 | 2008-05-01 |  | 63d |  |
| 64 | 3.4.1.1 | Prepare emails, posters, memos, and other information |  | 209d? | 2007-07-16 | 2008-05-01 |  | 63d | start no earlier than 2007-07-16 |
| 65 | 3.4.1.2 | Plan and hold meetings |  | 208d? | 2007-07-17 | 2008-05-01 |  | 63d | finish no earlier than 2008-05-01 |
| 66 | 3.4.1.3 | Prepare information for the corporate intranet |  | 208d? | 2007-07-17 | 2008-05-01 |  | 63d | finish no earlier than 2008-05-01 |
| 67 | 3.4.2 | Communications regarding productivity improvements |  | 40d | 2008-04-07 | 2008-06-02 | 58FS-5% | 41.5d |  |
| 68 | 4 | Monitoring and Controlling |  | 240d | 2007-07-02 | 2008-05-30 |  | 42d | start no earlier than 2007-07-02 |
| 69 | 5 | Closing |  | 21d | 2008-07-01 | 2008-07-29 | 61 | 0d | start no earlier than 2008-05-01 |
| 70 | 6 | Project buffer |  | 22d | 2008-05-30 | 2008-06-30 |  | 21d | start no earlier than 2008-05-30 |
| 71 | 7 | Project must be completed by date | milestone | 0d | 2008-06-30 | 2008-06-30 |  | 21d | finish no earlier than 2008-06-30 |
